# Office Renovation

How a schedule from MS Project changed from version to version. A marks actual dates.

## Version 1 (saved 2022-01-19, file Lesson 5 Lead Lag.mpp)

| ID | WBS | Task | Duration | Start | Finish | Predecessors | Total float |
| --- | --- | --- | --- | --- | --- | --- | --- |
| 1 | 1 | **Planning & Research** | 9d | 2022-04-04 | 2022-04-14 |  | 0d |
| 2 |  | Develop Requirements Documentation | 1d | 2022-04-04 | 2022-04-04 |  | 0d |
| 3 |  | Fit-Out Consultant Research & Engagement | 2d | 2022-04-05 | 2022-04-06 | 2 | 0d |
| 4 |  | IT Network Contractor Research & Engagement | 2d | 2022-04-07 | 2022-04-08 | 3 | 0d |
| 5 |  | Building Contractor Research & Engagement | 2d | 2022-04-11 | 2022-04-12 | 4 | 0d |
| 6 |  | Submit Requirements to Resources & Request Quotes | 1d | 2022-04-13 | 2022-04-13 | 5 | 0d |
| 7 |  | Quotes Received | 1d | 2022-04-14 | 2022-04-14 | 6 | 0d |
| 8 |  | Planning & Research Complete | 0d | 2022-04-14 | 2022-04-14 | 7 | 0d |
| 9 | 2 | **Management Approval** | 5d | 2022-04-15 | 2022-04-21 |  | 0d |
| 10 |  | Consolidate Quotes and develop proposal | 2d | 2022-04-15 | 2022-04-18 | 8 | 0d |
| 11 |  | Develop Project Plan & Durations | 2d | 2022-04-19 | 2022-04-20 | 10 | 0d |
| 12 |  | Submit Project Plan & Costs to Management | 1d | 2022-04-21 | 2022-04-21 | 11 | 0d |
| 13 |  | Management Approval Received | 0d | 2022-04-21 | 2022-04-21 | 12 | 0d |
| 14 | 3 | **Refit Office** | 14d? | 2022-04-22 | 2022-05-11 |  | 0d |
| 15 |  | Appoint Resources | 1d | 2022-04-22 | 2022-04-22 | 13 | 0d |
| 16 |  | Staff Briefing | 1d | 2022-04-25 | 2022-04-25 | 15 | 0d |
| 17 | 3.3 | **Fit-Out Consultations** | 4d | 2022-04-26 | 2022-04-29 |  | 0d |
| 18 |  | Design office space/structure plan | 1d | 2022-04-26 | 2022-04-26 | 16 | 0d |
| 19 |  | Select & Order Carpet | 1d | 2022-04-27 | 2022-04-27 | 18 | 6d |
| 20 |  | Select & Order Paint | 1d | 2022-04-27 | 2022-04-27 | 19SS | 6d |
| 21 |  | Select & Order Office Furniture | 1d | 2022-04-28 | 2022-04-28 | 20 | 6d |
| 22 |  | Select & Order digital PBX | 1d | 2022-04-29 | 2022-04-29 | 21 | 6d |
| 23 | 3.4 | **IT consultations** | 4d | 2022-04-26 | 2022-04-29 |  | 0d |
| 24 |  | Design IT network and phone points map | 1d | 2022-04-26 | 2022-04-26 | 16 | 0d |
| 25 |  | Select & Order New PCs | 1d | 2022-04-27 | 2022-04-27 | 24 | 7d |
| 26 |  | New PCs Arrive | 0.5d | 2022-04-28 | 2022-04-28 | 25 | 7d |
| 27 |  | Configure SOE on PCs | 1.5d | 2022-04-28 | 2022-04-29 | 26 | 7d |
| 28 | 3.5 | **Refit Office** | 11d? | 2022-04-27 | 2022-05-11 |  | 0d |
| 29 |  | Erect New Walls | 2d | 2022-04-27 | 2022-04-28 | 18, 24 | 0d |
| 30 |  | Gyprock, Plaster & Finish | 2d | 2022-04-29 | 2022-05-02 | 29 | 0d |
| 31 |  | Install Network & Phone Points | 1d | 2022-05-03 | 2022-05-03 | 30 | 0d |
| 32 |  | Painting | 2d | 2022-05-04 | 2022-05-05 | 31 | 0d |
| 33 |  | Lay new carpets | 1d | 2022-05-06 | 2022-05-06 | 32 | 0d |
| 34 |  | Install PBX hardware | 1d? | 2022-05-09 | 2022-05-09 | 22, 33 | 1d |
| 35 |  | Install New Furniture | 2d | 2022-05-09 | 2022-05-10 | 21, 33 | 0d |
| 36 |  | Connect and install PCs and phones | 1d | 2022-05-11 | 2022-05-11 | 27, 34, 35 | 0d |
| 37 |  | Refit Office Complete | 0d | 2022-05-11 | 2022-05-11 | 36 | 0d |
| 38 | 4 | **Office Move** | 17d | 2022-04-26 | 2022-05-18 |  | 0d |
| 39 |  | Order packing boxes | 0.5d | 2022-04-26 | 2022-04-26 | 16 | 11.5d |
| 40 |  | Staff Pack | 1d | 2022-05-12 | 2022-05-12 | 37, 39 | 0d |
| 41 |  | Staff Move | 2d | 2022-05-13 | 2022-05-16 | 40 | 0d |
| 42 |  | Office cleaning | 2d | 2022-05-17 | 2022-05-18 | 41 | 0d |
| 43 |  | Office Move Complete | 0d | 2022-05-18 | 2022-05-18 | 42 | 0d |

## Version 2 (saved 2022-01-19, file Lesson 6 Critical Path.mpp)

Last finish 2022-05-18 → 2022-05-25 (+7d).

Changed:

| ID | Task | Start | Finish | Duration | Total float | Predecessors |
| --- | --- | --- | --- | --- | --- | --- |
| 1 | **Planning & Research** |  | 2022-04-14 → 2022-04-21 (+7d) | 9d → 14d | 0d → 1d |  |
| 7 | Quotes Received | 2022-04-14 → 2022-04-21 (+7d) | 2022-04-14 → 2022-04-21 (+7d) |  | 0d → 1d | 6 → 6FS+5d |
| 8 | Planning & Research Complete | 2022-04-14 → 2022-04-21 (+7d) | 2022-04-14 → 2022-04-21 (+7d) |  | 0d → 1d |  |
| 9 | **Management Approval** | 2022-04-15 → 2022-04-22 (+7d) | 2022-04-21 → 2022-04-28 (+7d) |  | 0d → 1d |  |
| 10 | Consolidate Quotes and develop proposal | 2022-04-15 → 2022-04-22 (+7d) | 2022-04-18 → 2022-04-25 (+7d) |  | 0d → 1d |  |
| 11 | Develop Project Plan & Durations | 2022-04-19 → 2022-04-26 (+7d) | 2022-04-20 → 2022-04-27 (+7d) |  | 0d → 1d |  |
| 12 | Submit Project Plan & Costs to Management | 2022-04-21 → 2022-04-28 (+7d) | 2022-04-21 → 2022-04-28 (+7d) |  | 0d → 1d |  |
| 13 | Management Approval Received | 2022-04-21 → 2022-04-28 (+7d) | 2022-04-21 → 2022-04-28 (+7d) |  | 0d → 1d |  |
| 14 | **Refit Office** | 2022-04-22 → 2022-04-29 (+7d) | 2022-05-11 → 2022-05-18 (+7d) | 14d? → 14d |  |  |
| 15 | Appoint Resources | 2022-04-22 → 2022-04-29 (+7d) | 2022-04-22 → 2022-04-29 (+7d) |  | 0d → 1d |  |
| 16 | Staff Briefing | 2022-04-25 → 2022-05-02 (+7d) | 2022-04-25 → 2022-05-02 (+7d) |  | 0d → 1d |  |
| 17 | **Fit-Out Consultations** | 2022-04-26 → 2022-05-03 (+7d) | 2022-04-29 → 2022-05-06 (+7d) |  | 0d → 1d |  |
| 18 | Design office space/structure plan | 2022-04-26 → 2022-05-03 (+7d) | 2022-04-26 → 2022-05-03 (+7d) |  | 0d → 1d |  |
| 19 | Select & Order Carpet | 2022-04-27 → 2022-05-04 (+7d) | 2022-04-27 → 2022-05-04 (+7d) |  |  |  |
| 20 | Select & Order Paint | 2022-04-27 → 2022-05-04 (+7d) | 2022-04-27 → 2022-05-04 (+7d) |  |  |  |
| 21 | Select & Order Office Furniture | 2022-04-28 → 2022-05-05 (+7d) | 2022-04-28 → 2022-05-05 (+7d) |  |  |  |
| 22 | Select & Order digital PBX | 2022-04-29 → 2022-05-06 (+7d) | 2022-04-29 → 2022-05-06 (+7d) |  |  |  |
| 23 | **IT consultations** | 2022-04-26 → 2022-05-03 (+7d) | 2022-04-29 → 2022-05-17 (+18d) | 4d → 11d |  |  |
| 24 | Design IT network and phone points map | 2022-04-26 → 2022-05-03 (+7d) | 2022-04-26 → 2022-05-03 (+7d) |  | 0d → 1d |  |
| 25 | Select & Order New PCs | 2022-04-27 → 2022-05-04 (+7d) | 2022-04-27 → 2022-05-04 (+7d) |  | 7d → 1d |  |
| 26 | New PCs Arrive | 2022-04-28 → 2022-05-16 (+18d) | 2022-04-28 → 2022-05-16 (+18d) |  | 7d → 0d | 25 → 25FS+10ed |
| 27 | Configure SOE on PCs | 2022-04-28 → 2022-05-16 (+18d) | 2022-04-29 → 2022-05-17 (+18d) |  | 7d → 0d |  |
| 28 | **Refit Office** | 2022-04-27 → 2022-05-04 (+7d) | 2022-05-11 → 2022-05-18 (+7d) | 11d? → 11d |  |  |
| 29 | Erect New Walls | 2022-04-27 → 2022-05-04 (+7d) | 2022-04-28 → 2022-05-05 (+7d) |  | 0d → 1d |  |
| 30 | Gyprock, Plaster & Finish | 2022-04-29 → 2022-05-05 (+6d) | 2022-05-02 → 2022-05-06 (+4d) |  | 0d → 1d | 29 → 29FS-1d |
| 31 | Install Network & Phone Points | 2022-05-03 → 2022-05-09 (+6d) | 2022-05-03 → 2022-05-09 (+6d) |  | 0d → 1d |  |
| 32 | Painting | 2022-05-04 → 2022-05-10 (+6d) | 2022-05-05 → 2022-05-11 (+6d) |  | 0d → 1d |  |
| 33 | Lay new carpets | 2022-05-06 → 2022-05-12 (+6d) | 2022-05-06 → 2022-05-12 (+6d) |  | 0d → 1d |  |
| 34 | Install PBX hardware | 2022-05-09 → 2022-05-13 (+4d) | 2022-05-09 → 2022-05-13 (+4d) | 1d? → 1d | 1d → 2d |  |
| 35 | Install New Furniture | 2022-05-09 → 2022-05-13 (+4d) | 2022-05-10 → 2022-05-16 (+6d) |  | 0d → 1d |  |
| 36 | Connect and install PCs and phones | 2022-05-11 → 2022-05-18 (+7d) | 2022-05-11 → 2022-05-18 (+7d) |  |  |  |
| 37 | Refit Office Complete | 2022-05-11 → 2022-05-18 (+7d) | 2022-05-11 → 2022-05-18 (+7d) |  |  |  |
| 38 | **Office Move** | 2022-04-26 → 2022-05-03 (+7d) | 2022-05-18 → 2022-05-25 (+7d) |  |  |  |
| 39 | Order packing boxes | 2022-04-26 → 2022-05-03 (+7d) | 2022-04-26 → 2022-05-03 (+7d) |  |  |  |
| 40 | Staff Pack | 2022-05-12 → 2022-05-19 (+7d) | 2022-05-12 → 2022-05-19 (+7d) |  |  |  |
| 41 | Staff Move | 2022-05-13 → 2022-05-20 (+7d) | 2022-05-16 → 2022-05-23 (+7d) |  |  |  |
| 42 | Office cleaning | 2022-05-17 → 2022-05-24 (+7d) | 2022-05-18 → 2022-05-25 (+7d) |  |  |  |
| 43 | Office Move Complete | 2022-05-18 → 2022-05-25 (+7d) | 2022-05-18 → 2022-05-25 (+7d) |  |  |  |

## Version 3 (saved 2022-01-19, file Lesson 5 start.mpp)

Last finish 2022-05-25 → 2022-04-04 (-51d).

Changed:

| ID | Task | Start | Finish | Duration | Total float | Predecessors |
| --- | --- | --- | --- | --- | --- | --- |
| 1 | **Planning & Research** |  | 2022-04-21 → 2022-04-04 (-17d) | 14d → 1d? | 1d → 0d |  |
| 2 | Develop Requirements Documentation |  |  | 1d → 1d? | 1d → 0d |  |
| 3 | Fit-Out Consultant Research & Engagement | 2022-04-05 → 2022-04-04 (-1d) | 2022-04-06 → 2022-04-04 (-2d) | 2d → 1d? | 1d → 0d | 2 → none |
| 4 | IT Network Contractor Research & Engagement | 2022-04-07 → 2022-04-04 (-3d) | 2022-04-08 → 2022-04-04 (-4d) | 2d → 1d? | 1d → 0d | 3 → none |
| 5 | Building Contractor Research & Engagement | 2022-04-11 → 2022-04-04 (-7d) | 2022-04-12 → 2022-04-04 (-8d) | 2d → 1d? | 1d → 0d | 4 → none |
| 6 | Submit Requirements to Resources & Request Quotes | 2022-04-13 → 2022-04-04 (-9d) | 2022-04-13 → 2022-04-04 (-9d) | 1d → 1d? | 1d → 0d | 5 → none |
| 7 | Quotes Received | 2022-04-21 → 2022-04-04 (-17d) | 2022-04-21 → 2022-04-04 (-17d) | 1d → 1d? | 1d → 0d | 6FS+5d → none |
| 8 | Planning & Research Complete | 2022-04-21 → 2022-04-04 (-17d) | 2022-04-21 → 2022-04-04 (-17d) |  |  | 7 → none |
| 9 | **Management Approval** | 2022-04-22 → 2022-04-04 (-18d) | 2022-04-28 → 2022-04-04 (-24d) | 5d → 1d? | 1d → 0d |  |
| 10 | Consolidate Quotes and develop proposal | 2022-04-22 → 2022-04-04 (-18d) | 2022-04-25 → 2022-04-04 (-21d) | 2d → 1d? | 1d → 0d | 8 → none |
| 11 | Develop Project Plan & Durations | 2022-04-26 → 2022-04-04 (-22d) | 2022-04-27 → 2022-04-04 (-23d) | 2d → 1d? | 1d → 0d | 10 → none |
| 12 | Submit Project Plan & Costs to Management | 2022-04-28 → 2022-04-04 (-24d) | 2022-04-28 → 2022-04-04 (-24d) | 1d → 1d? | 1d → 0d | 11 → none |
| 13 | Management Approval Received | 2022-04-28 → 2022-04-04 (-24d) | 2022-04-28 → 2022-04-04 (-24d) |  |  | 12 → none |
| 14 | **Refit Office** | 2022-04-29 → 2022-04-04 (-25d) | 2022-05-18 → 2022-04-04 (-44d) | 14d → 1d? |  |  |
| 15 | Appoint Resources | 2022-04-29 → 2022-04-04 (-25d) | 2022-04-29 → 2022-04-04 (-25d) | 1d → 1d? | 1d → 0d | 13 → none |
| 16 | Staff Briefing | 2022-05-02 → 2022-04-04 (-28d) | 2022-05-02 → 2022-04-04 (-28d) | 1d → 1d? | 1d → 0d | 15 → none |
| 17 | **Fit-Out Consultations** | 2022-05-03 → 2022-04-04 (-29d) | 2022-05-06 → 2022-04-04 (-32d) | 4d → 1d? | 1d → 0d |  |
| 18 | Design office space/structure plan | 2022-05-03 → 2022-04-04 (-29d) | 2022-05-03 → 2022-04-04 (-29d) | 1d → 1d? | 1d → 0d | 16 → none |
| 19 | Select & Order Carpet | 2022-05-04 → 2022-04-04 (-30d) | 2022-05-04 → 2022-04-04 (-30d) | 1d → 1d? | 6d → 0d | 18 → none |
| 20 | Select & Order Paint | 2022-05-04 → 2022-04-04 (-30d) | 2022-05-04 → 2022-04-04 (-30d) | 1d → 1d? | 6d → 0d | 19SS → none |
| 21 | Select & Order Office Furniture | 2022-05-05 → 2022-04-04 (-31d) | 2022-05-05 → 2022-04-04 (-31d) | 1d → 1d? | 6d → 0d | 20 → none |
| 22 | Select & Order digital PBX | 2022-05-06 → 2022-04-04 (-32d) | 2022-05-06 → 2022-04-04 (-32d) | 1d → 1d? | 6d → 0d | 21 → none |
| 23 | **IT consultations** | 2022-05-03 → 2022-04-04 (-29d) | 2022-05-17 → 2022-04-04 (-43d) | 11d → 1d? |  |  |
| 24 | Design IT network and phone points map | 2022-05-03 → 2022-04-04 (-29d) | 2022-05-03 → 2022-04-04 (-29d) | 1d → 1d? | 1d → 0d | 16 → none |
| 25 | Select & Order New PCs | 2022-05-04 → 2022-04-04 (-30d) | 2022-05-04 → 2022-04-04 (-30d) | 1d → 1d? | 1d → 0d | 24 → none |
| 26 | New PCs Arrive | 2022-05-16 → 2022-04-04 (-42d) | 2022-05-16 → 2022-04-04 (-42d) | 0.5d → 1d? |  | 25FS+10ed → none |
| 27 | Configure SOE on PCs | 2022-05-16 → 2022-04-04 (-42d) | 2022-05-17 → 2022-04-04 (-43d) | 1.5d → 1d? |  | 26 → none |
| 28 | **Refit Office** | 2022-05-04 → 2022-04-04 (-30d) | 2022-05-18 → 2022-04-04 (-44d) | 11d → 1d? |  |  |
| 29 | Erect New Walls | 2022-05-04 → 2022-04-04 (-30d) | 2022-05-05 → 2022-04-04 (-31d) | 2d → 1d? | 1d → 0d | 18, 24 → none |
| 30 | Gyprock, Plaster & Finish | 2022-05-05 → 2022-04-04 (-31d) | 2022-05-06 → 2022-04-04 (-32d) | 2d → 1d? | 1d → 0d | 29FS-1d → none |
| 31 | Install Network & Phone Points | 2022-05-09 → 2022-04-04 (-35d) | 2022-05-09 → 2022-04-04 (-35d) | 1d → 1d? | 1d → 0d | 30 → none |
| 32 | Painting | 2022-05-10 → 2022-04-04 (-36d) | 2022-05-11 → 2022-04-04 (-37d) | 2d → 1d? | 1d → 0d | 31 → none |
| 33 | Lay new carpets | 2022-05-12 → 2022-04-04 (-38d) | 2022-05-12 → 2022-04-04 (-38d) | 1d → 1d? | 1d → 0d | 32 → none |
| 34 | Install PBX hardware | 2022-05-13 → 2022-04-04 (-39d) | 2022-05-13 → 2022-04-04 (-39d) | 1d → 1d? | 2d → 0d | 22, 33 → none |
| 35 | Install New Furniture | 2022-05-13 → 2022-04-04 (-39d) | 2022-05-16 → 2022-04-04 (-42d) | 2d → 1d? | 1d → 0d | 21, 33 → none |
| 36 | Connect and install PCs and phones | 2022-05-18 → 2022-04-04 (-44d) | 2022-05-18 → 2022-04-04 (-44d) | 1d → 1d? |  | 27, 34, 35 → none |
| 37 | Refit Office Complete | 2022-05-18 → 2022-04-04 (-44d) | 2022-05-18 → 2022-04-04 (-44d) |  | 0d → 1d | 36 → none |
| 38 | **Office Move** | 2022-05-03 → 2022-04-04 (-29d) | 2022-05-25 → 2022-04-04 (-51d) | 17d → 1d? |  |  |
| 39 | Order packing boxes | 2022-05-03 → 2022-04-04 (-29d) | 2022-05-03 → 2022-04-04 (-29d) | 0.5d → 1d? | 11.5d → 0d | 16 → none |
| 40 | Staff Pack | 2022-05-19 → 2022-04-04 (-45d) | 2022-05-19 → 2022-04-04 (-45d) | 1d → 1d? |  | 37, 39 → none |
| 41 | Staff Move | 2022-05-20 → 2022-04-04 (-46d) | 2022-05-23 → 2022-04-04 (-49d) | 2d → 1d? |  | 40 → none |
| 42 | Office cleaning | 2022-05-24 → 2022-04-04 (-50d) | 2022-05-25 → 2022-04-04 (-51d) | 2d → 1d? |  | 41 → none |
| 43 | Office Move Complete | 2022-05-25 → 2022-04-04 (-51d) | 2022-05-25 → 2022-04-04 (-51d) |  | 0d → 1d | 42 → none |

## Version 4 (saved 2022-01-19, file Lesson 7 Set Constraints.mpp)

Last finish 2022-04-04 → 2022-05-25 (+51d).

Changed:

| ID | Task | Start | Finish | Duration | Total float | Predecessors |
| --- | --- | --- | --- | --- | --- | --- |
| 1 | **Planning & Research** |  | 2022-04-04 → 2022-04-21 (+17d) | 1d? → 14d | 0d → 1d |  |
| 2 | Develop Requirements Documentation |  |  | 1d? → 1d | 0d → 1d |  |
| 3 | Fit-Out Consultant Research & Engagement | 2022-04-04 → 2022-04-05 (+1d) | 2022-04-04 → 2022-04-06 (+2d) | 1d? → 2d | 0d → 1d | none → 2 |
| 4 | IT Network Contractor Research & Engagement | 2022-04-04 → 2022-04-07 (+3d) | 2022-04-04 → 2022-04-08 (+4d) | 1d? → 2d | 0d → 1d | none → 3 |
| 5 | Building Contractor Research & Engagement | 2022-04-04 → 2022-04-11 (+7d) | 2022-04-04 → 2022-04-12 (+8d) | 1d? → 2d | 0d → 1d | none → 4 |
| 6 | Submit Requirements to Resources & Request Quotes | 2022-04-04 → 2022-04-13 (+9d) | 2022-04-04 → 2022-04-13 (+9d) | 1d? → 1d | 0d → 1d | none → 5 |
| 7 | Quotes Received | 2022-04-04 → 2022-04-21 (+17d) | 2022-04-04 → 2022-04-21 (+17d) | 1d? → 1d | 0d → 1d | none → 6FS+5d |
| 8 | Planning & Research Complete | 2022-04-04 → 2022-04-21 (+17d) | 2022-04-04 → 2022-04-21 (+17d) |  |  | none → 7 |
| 9 | **Management Approval** | 2022-04-04 → 2022-04-22 (+18d) | 2022-04-04 → 2022-04-28 (+24d) | 1d? → 5d | 0d → 1d |  |
| 10 | Consolidate Quotes and develop proposal | 2022-04-04 → 2022-04-22 (+18d) | 2022-04-04 → 2022-04-25 (+21d) | 1d? → 2d | 0d → 1d | none → 8 |
| 11 | Develop Project Plan & Durations | 2022-04-04 → 2022-04-26 (+22d) | 2022-04-04 → 2022-04-27 (+23d) | 1d? → 2d | 0d → 1d | none → 10 |
| 12 | Submit Project Plan & Costs to Management | 2022-04-04 → 2022-04-28 (+24d) | 2022-04-04 → 2022-04-28 (+24d) | 1d? → 1d | 0d → 1d | none → 11 |
| 13 | Management Approval Received | 2022-04-04 → 2022-04-28 (+24d) | 2022-04-04 → 2022-04-28 (+24d) |  |  | none → 12 |
| 14 | **Refit Office** | 2022-04-04 → 2022-04-29 (+25d) | 2022-04-04 → 2022-05-18 (+44d) | 1d? → 14d |  |  |
| 15 | Appoint Resources | 2022-04-04 → 2022-04-29 (+25d) | 2022-04-04 → 2022-04-29 (+25d) | 1d? → 1d | 0d → 1d | none → 13 |
| 16 | Staff Briefing | 2022-04-04 → 2022-05-02 (+28d) | 2022-04-04 → 2022-05-02 (+28d) | 1d? → 1d | 0d → 1d | none → 15 |
| 17 | **Fit-Out Consultations** | 2022-04-04 → 2022-05-03 (+29d) | 2022-04-04 → 2022-05-06 (+32d) | 1d? → 4d | 0d → 1d |  |
| 18 | Design office space/structure plan | 2022-04-04 → 2022-05-03 (+29d) | 2022-04-04 → 2022-05-03 (+29d) | 1d? → 1d | 0d → 1d | none → 16 |
| 19 | Select & Order Carpet | 2022-04-04 → 2022-05-04 (+30d) | 2022-04-04 → 2022-05-04 (+30d) | 1d? → 1d | 0d → 6d | none → 18 |
| 20 | Select & Order Paint | 2022-04-04 → 2022-05-04 (+30d) | 2022-04-04 → 2022-05-04 (+30d) | 1d? → 1d | 0d → 6d | none → 19SS |
| 21 | Select & Order Office Furniture | 2022-04-04 → 2022-05-05 (+31d) | 2022-04-04 → 2022-05-05 (+31d) | 1d? → 1d | 0d → 6d | none → 20 |
| 22 | Select & Order digital PBX | 2022-04-04 → 2022-05-06 (+32d) | 2022-04-04 → 2022-05-06 (+32d) | 1d? → 1d | 0d → 6d | none → 21 |
| 23 | **IT consultations** | 2022-04-04 → 2022-05-03 (+29d) | 2022-04-04 → 2022-05-17 (+43d) | 1d? → 11d |  |  |
| 24 | Design IT network and phone points map | 2022-04-04 → 2022-05-03 (+29d) | 2022-04-04 → 2022-05-03 (+29d) | 1d? → 1d | 0d → 1d | none → 16 |
| 25 | Select & Order New PCs | 2022-04-04 → 2022-05-04 (+30d) | 2022-04-04 → 2022-05-04 (+30d) | 1d? → 1d | 0d → 1d | none → 24 |
| 26 | New PCs Arrive | 2022-04-04 → 2022-05-16 (+42d) | 2022-04-04 → 2022-05-16 (+42d) | 1d? → 0.5d |  | none → 25FS+10ed |
| 27 | Configure SOE on PCs | 2022-04-04 → 2022-05-16 (+42d) | 2022-04-04 → 2022-05-17 (+43d) | 1d? → 1.5d |  | none → 26 |
| 28 | **Refit Office** | 2022-04-04 → 2022-05-04 (+30d) | 2022-04-04 → 2022-05-18 (+44d) | 1d? → 11d |  |  |
| 29 | Erect New Walls | 2022-04-04 → 2022-05-04 (+30d) | 2022-04-04 → 2022-05-05 (+31d) | 1d? → 2d | 0d → 1d | none → 18, 24 |
| 30 | Gyprock, Plaster & Finish | 2022-04-04 → 2022-05-05 (+31d) | 2022-04-04 → 2022-05-06 (+32d) | 1d? → 2d | 0d → 1d | none → 29FS-1d |
| 31 | Install Network & Phone Points | 2022-04-04 → 2022-05-09 (+35d) | 2022-04-04 → 2022-05-09 (+35d) | 1d? → 1d | 0d → 1d | none → 30 |
| 32 | Painting | 2022-04-04 → 2022-05-10 (+36d) | 2022-04-04 → 2022-05-11 (+37d) | 1d? → 2d | 0d → 1d | none → 31 |
| 33 | Lay new carpets | 2022-04-04 → 2022-05-12 (+38d) | 2022-04-04 → 2022-05-12 (+38d) | 1d? → 1d | 0d → 1d | none → 32 |
| 34 | Install PBX hardware | 2022-04-04 → 2022-05-13 (+39d) | 2022-04-04 → 2022-05-13 (+39d) | 1d? → 1d | 0d → 2d | none → 22, 33 |
| 35 | Install New Furniture | 2022-04-04 → 2022-05-13 (+39d) | 2022-04-04 → 2022-05-16 (+42d) | 1d? → 2d | 0d → 1d | none → 21, 33 |
| 36 | Connect and install PCs and phones | 2022-04-04 → 2022-05-18 (+44d) | 2022-04-04 → 2022-05-18 (+44d) | 1d? → 1d |  | none → 27, 34, 35 |
| 37 | Refit Office Complete | 2022-04-04 → 2022-05-18 (+44d) | 2022-04-04 → 2022-05-18 (+44d) |  | 1d → 0d | none → 36 |
| 38 | **Office Move** | 2022-04-04 → 2022-05-03 (+29d) | 2022-04-04 → 2022-05-25 (+51d) | 1d? → 17d |  |  |
| 39 | Order packing boxes | 2022-04-04 → 2022-05-03 (+29d) | 2022-04-04 → 2022-05-03 (+29d) | 1d? → 0.5d | 0d → 11.5d | none → 16 |
| 40 | Staff Pack | 2022-04-04 → 2022-05-19 (+45d) | 2022-04-04 → 2022-05-19 (+45d) | 1d? → 1d |  | none → 37, 39 |
| 41 | Staff Move | 2022-04-04 → 2022-05-20 (+46d) | 2022-04-04 → 2022-05-23 (+49d) | 1d? → 2d |  | none → 40 |
| 42 | Office cleaning | 2022-04-04 → 2022-05-24 (+50d) | 2022-04-04 → 2022-05-25 (+51d) | 1d? → 2d |  | none → 41 |
| 43 | Office Move Complete | 2022-04-04 → 2022-05-25 (+51d) | 2022-04-04 → 2022-05-25 (+51d) |  | 1d → 0d | none → 42 |

## Version 5 (saved 2022-01-19, file Lesson 8 Printing.mpp)

Last finish 2022-05-25 → 2022-06-10 (+16d).

Changed:

| ID | Task | Start | Finish | Duration | Total float |
| --- | --- | --- | --- | --- | --- |
| 14 | **Refit Office** |  | 2022-05-18 → 2022-06-05 (+18d) | 14d → 26d |  |
| 28 | **Refit Office** | 2022-05-04 → 2022-05-07 (+3d) | 2022-05-18 → 2022-06-05 (+18d) | 11d → 20d |  |
| 29 | Erect New Walls | 2022-05-04 → 2022-05-07 (+3d) | 2022-05-05 → 2022-05-08 (+3d) |  | 1d → 0d |
| 30 | Gyprock, Plaster & Finish | 2022-05-05 → 2022-05-08 (+3d) | 2022-05-06 → 2022-05-14 (+8d) |  | 1d → 0d |
| 31 | Install Network & Phone Points | 2022-05-09 → 2022-05-15 (+6d) | 2022-05-09 → 2022-05-15 (+6d) |  | 1d → 0d |
| 32 | Painting | 2022-05-10 → 2022-05-21 (+11d) | 2022-05-11 → 2022-05-22 (+11d) |  | 1d → 0d |
| 33 | Lay new carpets | 2022-05-12 → 2022-05-28 (+16d) | 2022-05-12 → 2022-05-28 (+16d) |  | 1d → 0d |
| 34 | Install PBX hardware | 2022-05-13 → 2022-05-29 (+16d) | 2022-05-13 → 2022-05-29 (+16d) |  | 2d → 1d |
| 35 | Install New Furniture | 2022-05-13 → 2022-05-29 (+16d) | 2022-05-16 → 2022-06-04 (+19d) |  | 1d → 0d |
| 36 | Connect and install PCs and phones | 2022-05-18 → 2022-06-05 (+18d) | 2022-05-18 → 2022-06-05 (+18d) |  |  |
| 37 | Refit Office Complete | 2022-05-18 → 2022-06-05 (+18d) | 2022-05-18 → 2022-06-05 (+18d) |  |  |
| 38 | **Office Move** |  | 2022-05-25 → 2022-06-10 (+16d) | 17d → 29d |  |
| 40 | Staff Pack | 2022-05-19 → 2022-06-06 (+18d) | 2022-05-19 → 2022-06-06 (+18d) |  |  |
| 41 | Staff Move | 2022-05-20 → 2022-06-07 (+18d) | 2022-05-23 → 2022-06-08 (+16d) |  |  |
| 42 | Office cleaning | 2022-05-24 → 2022-06-09 (+16d) | 2022-05-25 → 2022-06-10 (+16d) |  |  |
| 43 | Office Move Complete | 2022-05-25 → 2022-06-10 (+16d) | 2022-05-25 → 2022-06-10 (+16d) |  |  |

## Version 6 (saved 2022-01-19, file Lesson 9 Levelling.mpp)

Last finish stays 2022-06-10.

Changed:

| ID | Task | Other |
| --- | --- | --- |
| 2 | Develop Requirements Documentation | resources none → Project Manager |
| 3 | Fit-Out Consultant Research & Engagement | resources none → Project Manager |
| 4 | IT Network Contractor Research & Engagement | resources none → Project Manager |
| 5 | Building Contractor Research & Engagement | resources none → Project Manager |
| 6 | Submit Requirements to Resources & Request Quotes | resources none → Project Manager |
| 7 | Quotes Received | resources none → Project Manager |
| 10 | Consolidate Quotes and develop proposal | resources none → Project Manager |
| 11 | Develop Project Plan & Durations | resources none → Project Manager |
| 12 | Submit Project Plan & Costs to Management | resources none → Management; Project Manager |
| 15 | Appoint Resources | resources none → Project Manager |
| 16 | Staff Briefing | resources none → Project Manager; Staff [700%] |
| 18 | Design office space/structure plan | resources none → Fit-out Consultant; Project Manager |
| 19 | Select & Order Carpet | resources none → Fit-out Consultant; Project Manager |
| 20 | Select & Order Paint | resources none → Fit-out Consultant; Project Manager |
| 21 | Select & Order Office Furniture | resources none → Fit-out Consultant; Project Manager |
| 22 | Select & Order digital PBX | resources none → Fit-out Consultant; Project Manager |
| 24 | Design IT network and phone points map | resources none → IT Consultant; Project Manager |
| 25 | Select & Order New PCs | resources none → Project Manager |
| 26 | New PCs Arrive | resources none → Project Manager |
| 27 | Configure SOE on PCs | resources none → IT Consultant |
| 29 | Erect New Walls | resources none → Carpenter [200%] |
| 30 | Gyprock, Plaster & Finish | resources none → Plastering Contractor |
| 31 | Install Network & Phone Points | resources none → IT Consultant |
| 32 | Painting | resources none → Painter |
| 33 | Lay new carpets | resources none → Carpet Contractor |
| 34 | Install PBX hardware | resources none → IT Consultant |
| 35 | Install New Furniture | resources none → Labourer |
| 36 | Connect and install PCs and phones | resources none → IT Consultant |
| 39 | Order packing boxes | resources none → Project Manager |
| 40 | Staff Pack | resources none → Project Manager; Staff [2000%] |
| 41 | Staff Move | resources none → Staff [2000%]; Labourer |
| 42 | Office cleaning | resources none → Cleaner [200%] |

## Version 7 (saved 2022-01-19, file Lesson 10 Costs.mpp)

Last finish stays 2022-06-10.

Changed:

| ID | Task | Start | Finish | Duration | Total float | Predecessors | Other |
| --- | --- | --- | --- | --- | --- | --- | --- |
| 17 | **Fit-Out Consultations** |  | 2022-05-06 → 2022-05-09 (+3d) | 4d → 5d |  |  |  |
| 20 | Select & Order Paint | 2022-05-04 → 2022-05-05 (+1d) | 2022-05-04 → 2022-05-05 (+1d) |  | 16d → 15d | 19SS → 19 |  |
| 21 | Select & Order Office Furniture | 2022-05-05 → 2022-05-06 (+1d) | 2022-05-05 → 2022-05-06 (+1d) |  | 16d → 15d |  |  |
| 22 | Select & Order digital PBX | 2022-05-06 → 2022-05-09 (+3d) | 2022-05-06 → 2022-05-09 (+3d) |  | 20d → 19d |  |  |
| 24 | Design IT network and phone points map |  |  |  |  |  | resources IT Consultant; Project Manager → IT Consultant |
| 25 | Select & Order New PCs |  |  |  |  |  | resources Project Manager → IT Consultant |
| 39 | Order packing boxes |  |  |  |  |  | resources Project Manager → Admin Assistant |

## Version 8 (data date 2022-05-16, saved 2022-01-19, file Office Renovation completed.mpp)

Last finish 2022-06-10 → 2022-06-24 (+14d). Complete tasks 0 → 11.

Added:

| ID | Task | Duration | Start | Finish | Predecessors |
| --- | --- | --- | --- | --- | --- |
| 30 | Variation #1 - Fit out and install new reception area | 2d | 2022-05-21 | 2022-05-22 | 29 |

Changed:

| ID | Task | Start | Finish | Duration | Complete | Total float | Predecessors | Other |
| --- | --- | --- | --- | --- | --- | --- | --- | --- |
| 1 | **Planning & Research** | 2022-04-04 A | 2022-04-21 → 2022-04-26 A (+5d) | 14d → 16d | 0% → 100% | 3d → none |  | baseline start none → 2022-04-04; baseline finish none → 2022-04-26 |
| 2 | Develop Requirements Documentation | 2022-04-04 A | 2022-04-04 A |  | 0% → 100% | 3d → none |  | baseline start none → 2022-04-04; baseline finish none → 2022-04-04 |
| 3 | Fit-Out Consultant Research & Engagement | 2022-04-05 A | 2022-04-06 A |  | 0% → 100% | 3d → none |  | baseline start none → 2022-04-05; baseline finish none → 2022-04-06 |
| 4 | IT Network Contractor Research & Engagement | 2022-04-07 A | 2022-04-08 A |  | 0% → 100% | 3d → none |  | baseline start none → 2022-04-07; baseline finish none → 2022-04-08 |
| 5 | Building Contractor Research & Engagement | 2022-04-11 → 2022-04-13 A (+2d) | 2022-04-12 → 2022-04-14 A (+2d) |  | 0% → 100% | 3d → none |  | baseline start none → 2022-04-13; baseline finish none → 2022-04-14 |
| 6 | Submit Requirements to Resources & Request Quotes | 2022-04-13 → 2022-04-15 A (+2d) | 2022-04-13 → 2022-04-15 A (+2d) |  | 0% → 100% | 3d → none |  | baseline start none → 2022-04-15; baseline finish none → 2022-04-15 |
| 7 | Quotes Received | 2022-04-21 → 2022-04-25 A (+4d) | 2022-04-21 → 2022-04-25 A (+4d) |  | 0% → 100% | 3d → none |  | baseline start none → 2022-04-25; baseline finish none → 2022-04-25 |
| 8 | Planning & Research Complete | 2022-04-21 → 2022-04-26 A (+5d) | 2022-04-21 → 2022-04-26 A (+5d) |  | 0% → 100% | 3d → none |  | baseline start none → 2022-04-26; baseline finish none → 2022-04-26 |
| 9 | **Management Approval** | 2022-04-22 → 2022-04-26 A (+4d) | 2022-04-28 → 2022-05-10 A (+12d) | 5d → 10d | 0% → 100% | 3d → none |  | baseline start none → 2022-04-26; baseline finish none → 2022-05-10 |
| 10 | Consolidate Quotes and develop proposal | 2022-04-22 → 2022-04-26 A (+4d) | 2022-04-25 → 2022-04-27 A (+2d) |  | 0% → 100% | 3d → none |  | baseline start none → 2022-04-26; baseline finish none → 2022-04-27 |
| 11 | Develop Project Plan & Durations | 2022-04-26 → 2022-04-28 A (+2d) | 2022-04-27 → 2022-04-29 A (+2d) |  | 0% → 100% | 3d → none |  | baseline start none → 2022-04-28; baseline finish none → 2022-04-29 |
| 12 | Submit Project Plan & Costs to Management | 2022-04-28 → 2022-05-03 A (+5d) | 2022-04-28 → 2022-05-03 A (+5d) |  | 0% → 100% | 3d → none |  | baseline start none → 2022-05-03; baseline finish none → 2022-05-03 |
| 13 | Management Approval Received | 2022-04-28 → 2022-05-10 A (+12d) | 2022-04-28 → 2022-05-10 A (+12d) |  | 0% → 100% | 3d → none |  | baseline start none → 2022-05-10; baseline finish none → 2022-05-10 |
| 14 | **Refit Office** | 2022-04-29 → 2022-05-10 (+11d) | 2022-06-05 → 2022-06-18 (+13d) | 26d → 29d |  |  |  | baseline start none → 2022-05-10; baseline finish none → 2022-06-18 |
| 15 | Appoint Resources | 2022-04-29 → 2022-05-10 (+11d) | 2022-04-29 → 2022-05-10 (+11d) |  |  | 3d → 1d |  | baseline start none → 2022-05-10; baseline finish none → 2022-05-10 |
| 16 | Staff Briefing | 2022-05-02 → 2022-05-11 (+9d) | 2022-05-02 → 2022-05-11 (+9d) |  |  | 3d → 1d |  | baseline start none → 2022-05-11; baseline finish none → 2022-05-11 |
| 17 | **Fit-Out Consultations** | 2022-05-03 → 2022-05-12 (+9d) | 2022-05-09 → 2022-05-18 (+9d) |  |  | 3d → 1d |  | baseline start none → 2022-05-12; baseline finish none → 2022-05-18 |
| 18 | Design office space/structure plan | 2022-05-03 → 2022-05-12 (+9d) | 2022-05-03 → 2022-05-12 (+9d) |  |  | 3d → 1d |  | baseline start none → 2022-05-12; baseline finish none → 2022-05-12 |
| 19 | Select & Order Carpet | 2022-05-04 → 2022-05-13 (+9d) | 2022-05-04 → 2022-05-13 (+9d) |  |  | 15d → 22d |  | baseline start none → 2022-05-13; baseline finish none → 2022-05-13 |
| 20 | Select & Order Paint | 2022-05-05 → 2022-05-16 (+11d) | 2022-05-05 → 2022-05-16 (+11d) |  |  | 15d → 22d |  | baseline start none → 2022-05-16; baseline finish none → 2022-05-16 |
| 21 | Select & Order Office Furniture | 2022-05-06 → 2022-05-17 (+11d) | 2022-05-06 → 2022-05-17 (+11d) |  |  | 15d → 22d |  | baseline start none → 2022-05-17; baseline finish none → 2022-05-17 |
| 22 | Select & Order digital PBX | 2022-05-09 → 2022-05-18 (+9d) | 2022-05-09 → 2022-05-18 (+9d) |  |  | 19d → 22d |  | baseline start none → 2022-05-18; baseline finish none → 2022-05-18 |
| 23 | **IT consultations** | 2022-05-03 → 2022-05-12 (+9d) | 2022-05-17 → 2022-05-25 (+8d) | 11d → 10d |  | 3d → 1d |  | baseline start none → 2022-05-12; baseline finish none → 2022-05-25 |
| 24 | Design IT network and phone points map | 2022-05-03 → 2022-05-12 (+9d) | 2022-05-03 → 2022-05-12 (+9d) |  |  | 3d → 1d |  | baseline start none → 2022-05-12; baseline finish none → 2022-05-12 |
| 25 | Select & Order New PCs | 2022-05-04 → 2022-05-13 (+9d) | 2022-05-04 → 2022-05-13 (+9d) |  |  | 12d → 15d |  | baseline start none → 2022-05-13; baseline finish none → 2022-05-13 |
| 26 | New PCs Arrive | 2022-05-16 → 2022-05-24 (+8d) | 2022-05-16 → 2022-05-24 (+8d) |  |  | 13d → 17d |  | baseline start none → 2022-05-24; baseline finish none → 2022-05-24 |
| 27 | Configure SOE on PCs | 2022-05-16 → 2022-05-24 (+8d) | 2022-05-17 → 2022-05-25 (+8d) |  |  | 13d → 17d |  | baseline start none → 2022-05-24; baseline finish none → 2022-05-25 |
| 28 | **Refit Office** | 2022-05-07 → 2022-05-14 (+7d) | 2022-06-05 → 2022-06-18 (+13d) | 20d → 25d |  |  |  | baseline start none → 2022-05-14; baseline finish none → 2022-06-18 |
| 29 | Erect New Walls | 2022-05-07 → 2022-05-14 (+7d) | 2022-05-08 → 2022-05-15 (+7d) |  |  | 0d → 1d |  | baseline start none → 2022-05-14; baseline finish none → 2022-05-15 |
| 31 | Gyprock, Plaster & Finish | 2022-05-08 → 2022-05-28 (+20d) | 2022-05-14 → 2022-05-28 (+14d) | 2d → 1d |  | 0d → 1d | 29FS-1d → 29FS-1d, 30 | baseline start none → 2022-05-28; baseline finish none → 2022-05-28 |
| 32 | Install Network & Phone Points | 2022-05-15 → 2022-05-29 (+14d) | 2022-05-15 → 2022-05-29 (+14d) |  |  | 0d → 1d |  | baseline start none → 2022-05-29; baseline finish none → 2022-05-29 |
| 33 | Painting | 2022-05-21 → 2022-06-04 (+14d) | 2022-05-22 → 2022-06-05 (+14d) |  |  | 0d → 1d |  | baseline start none → 2022-06-04; baseline finish none → 2022-06-05 |
| 34 | Lay new carpets | 2022-05-28 → 2022-06-11 (+14d) | 2022-05-28 → 2022-06-11 (+14d) |  |  | 0d → 1d |  | baseline start none → 2022-06-11; baseline finish none → 2022-06-11 |
| 35 | Install PBX hardware | 2022-05-29 → 2022-06-12 (+14d) | 2022-05-29 → 2022-06-12 (+14d) |  |  |  |  | baseline start none → 2022-06-12; baseline finish none → 2022-06-12 |
| 36 | Install New Furniture | 2022-05-29 → 2022-06-12 (+14d) | 2022-06-04 → 2022-06-12 (+8d) | 2d → 1d |  | 0d → 1d |  | baseline start none → 2022-06-12; baseline finish none → 2022-06-12 |
| 37 | Connect and install PCs and phones | 2022-06-05 → 2022-06-18 (+13d) | 2022-06-05 → 2022-06-18 (+13d) |  |  | 0d → 1d |  | baseline start none → 2022-06-18; baseline finish none → 2022-06-18 |
| 38 | Refit Office Complete | 2022-06-05 → 2022-06-18 (+13d) | 2022-06-05 → 2022-06-18 (+13d) |  |  |  |  | baseline start none → 2022-06-18; baseline finish none → 2022-06-18 |
| 39 | **Office Move** | 2022-05-03 → 2022-05-12 (+9d) | 2022-06-10 → 2022-06-24 (+14d) | 29d → 32d |  |  |  | baseline start none → 2022-05-12; baseline finish none → 2022-06-24 |
| 40 | Order packing boxes | 2022-05-03 → 2022-05-12 (+9d) | 2022-05-03 → 2022-05-12 (+9d) |  |  | 23.5d → 26.5d |  | baseline start none → 2022-05-12; baseline finish none → 2022-05-12 |
| 41 | Staff Pack | 2022-06-06 → 2022-06-20 (+14d) | 2022-06-06 → 2022-06-20 (+14d) |  |  |  |  | baseline start none → 2022-06-20; baseline finish none → 2022-06-20 |
| 42 | Staff Move | 2022-06-07 → 2022-06-21 (+14d) | 2022-06-08 → 2022-06-22 (+14d) |  |  |  |  | baseline start none → 2022-06-21; baseline finish none → 2022-06-22 |
| 43 | Office cleaning | 2022-06-09 → 2022-06-23 (+14d) | 2022-06-10 → 2022-06-24 (+14d) |  |  |  |  | baseline start none → 2022-06-23; baseline finish none → 2022-06-24 |
| 44 | Office Move Complete | 2022-06-10 → 2022-06-24 (+14d) | 2022-06-10 → 2022-06-24 (+14d) |  |  |  |  | baseline start none → 2022-06-24; baseline finish none → 2022-06-24 |
